# 311-planningglobal integration V2 du 03-11-15

Schedule from MS Project, 2015-12-15 to 2017-10-16, 7 hours a day.

## Calendars

- Standard: Mon-Fri 09:00-12:00, 14:00-18:00; Sat-Sun off.

## Resources

| Resource |
| --- |
| Tous |
| Utilisateurs |
| Delta |
| CERN |
| CERN H-VAC |
| CERN Utilisateurs |
| GEOS |
| Delta Thermifluides |
| Administration |
| ENTREPRISE |
| ENTREPRISE G. |
| GEOS/DELTA/CERN |

## Schedule

| ID | WBS | Task | Duration | Start | Finish | Predecessors | Total slack | Free slack |
| --- | --- | --- | --- | --- | --- | --- | --- | --- |
| 1 | 0 | **CONSTRUCTION B311** | 306d | 2016-03-01 | 2017-05-02 |  | 0d |  |
| 2 | 1.1 | **Installations de chantier** | 6d | 2016-03-01 | 2016-03-08 |  | 0d |  |
| 3 | 1.1.1 | Mise en place barrière RAS | 1d | 2016-03-01 | 2016-03-01 |  | 0d |  |
| 4 | 1.1.2 | Installations de chantier (baraquements etc.) | 1w | 2016-03-02 | 2016-03-08 | 3 | 418d | 0d |
| 5 | 1.1.3 | Aménagement voie d'accès, signalisation routière, marquage au sol, etc. | 2d | 2016-03-02 | 2016-03-03 | 3 | 421d | 3d |
| 6 | 1.2 | **Terrassement, canalisation, démolition** | 165d | 2016-03-02 | 2016-10-18 |  | 4d |  |
| 7 | 1.2.1 | Démontage candélabres CERN et mise hors tension | 1d | 2016-03-02 | 2016-03-02 | 3 | 423d |  |
| 8 | 1.2.2 | Décapage terre végétale, pré-terrassement | 3d | 2016-03-08 | 2016-03-10 | 21 | 0d |  |
| 9 | 1.2.3 | Déviation réseaux existants | 1w | 2016-03-11 | 2016-03-17 | 8 | 0d |  |
| 10 | 1.2.4 | Démolition, récupération et évacuation matériau de démol. | 1w | 2016-03-18 | 2016-03-24 | 9 | 0d |  |
| 11 | 1.2.5 | Terrassement à +30cm du fond de fouille | 1w | 2016-03-25 | 2016-03-31 | 10 | 0d |  |
| 12 | 1.2.6 | Fouille, couche de forme et canalisations sous FF | 4w | 2016-04-22 | 2016-05-19 | 22 | 0d |  |
| 13 | 1.2.7 | Fouille bassin de rétention | 3d | 2016-04-22 | 2016-04-26 | 22 | 0d |  |
| 14 | 1.2.8 | Terrassement jusqu' au FF y.c. tranchée longrine et caniveaux +géotextile + béton maigre ép. 10cm | 1w | 2016-05-11 | 2016-05-17 | 23 | 0d |  |
| 15 | 1.2.9 | Remblayage Misapor ép 30cm | 1w | 2016-06-15 | 2016-06-21 | 24 | 0d |  |
| 16 | 1.2.10 | Mise en place canalisation dans Misapor | 3d | 2016-06-22 | 2016-06-24 | 15 | 0d |  |
| 17 | 1.2.11 | Feuille plastique + BM sur Misapor | 1d | 2016-06-27 | 2016-06-27 | 16 | 0d |  |
| 18 | 1.2.12 | Mise à terre | 1d | 2016-06-28 | 2016-06-28 | 17 | 0d |  |
| 19 | 1.2.13 | Remblayage contre ouvrage et aménagement extérieurs | 1w | 2016-10-12 | 2016-10-18 | 28, 31 | 0d |  |
| 20 | 1.3 | **Béton** | 161d | 2016-03-01 | 2016-10-11 |  | 0d |  |
| 21 | 1.3.1 | Radier protection sur chambre de vannes | 1w | 2016-03-01 | 2016-03-07 | 3SS | 0d |  |
| 22 | 1.3.2 | Pieux et travaux spéciaux | 3w | 2016-04-01 | 2016-04-21 | 11 | 0d |  |
| 23 | 1.3.3 | Coffrage + bétonnage bassin rétention | 2w | 2016-04-27 | 2016-05-10 | 13 | 0d |  |
| 24 | 1.3.4 | Bétonnage tête de pieux, caniveaux, longrines fondations | 4w | 2016-05-18 | 2016-06-14 | 14 | 0d |  |
| 25 | 1.3.5 | Radier | 3w | 2016-06-29 | 2016-07-19 | 18 | 0d |  |
| 26 | 1.3.6 | Dallage isolé | 1w | 2016-07-20 | 2016-07-26 | 25 | 10d |  |
| 27 | 1.3.7 | Remontées, murets, murs soubassement | 3w | 2016-07-20 | 2016-08-09 | 25, 114 | 0d |  |
| 28 | 1.3.8 | Barapren, isolation, delta MS | 2w | 2016-08-10 | 2016-08-23 | 27 | 35d |  |
| 29 | 1.3.9 | Cage ascenseur | 2w | 2016-07-20 | 2016-08-02 | 25 | 5d |  |
| 30 | 1.3.10 | Dalle mixte | 1w | 2016-09-21 | 2016-09-27 | 34 | 0d |  |
| 31 | 1.3.11 | Mur soutènement + rampe extérieure | 2w | 2016-09-28 | 2016-10-11 | 30 | 0d |  |

| ID | WBS | Task | Duration | Start | Finish | Predecessors | Total slack | Free slack |
| --- | --- | --- | --- | --- | --- | --- | --- | --- |
| 32 | 1.4 | **Construction métallique** | 30d | 2016-08-10 | 2016-09-20 |  | 0d |  |
| 33 | 1.4.1 | Debut pose charpente métallique | 4w | 2016-08-10 | 2016-09-06 | 25, 26, 27, 29 | 0d |  |
| 34 | 1.4.2 | Fin pose charpente | 1w | 2016-09-14 | 2016-09-20 | 111 | 0d |  |
| 35 | 1.5 | **Voirie** | 249d | 2016-03-09 | 2017-02-20 |  | 170d |  |
| 36 | 1.5.1 | Constat + inspection caméra drainage galerie existante | 1d | 2016-03-09 | 2016-03-09 | 4, 5 | 418d |  |
| 37 | 1.5.2 | Bordures | 1d | 2017-02-10 | 2017-02-10 | 41, 56 | 170d | 0d |
| 38 | 1.5.3 | Couche de forme + Enrobés | 1w | 2017-02-13 | 2017-02-17 | 37 | 170d | 0d |
| 39 | 1.5.4 | Nettoyage et contrôle caméra des canalisations | 1d | 2017-02-20 | 2017-02-20 | 38 | 170d |  |
| 40 | 1.6 | **Second oeuvre selon planning architecte** | 140d | 2016-10-19 | 2017-05-02 | 34, 19 | 0d |  |
| 41 | 1.6.1 | **Façades - bardages** | 82d | 2016-10-19 | 2017-02-09 | 34, 19 | 0d |  |
| 42 | 1.6.1.1 | plateaux porteurs | 10d | 2016-10-19 | 2016-11-01 |  | 0d |  |
| 43 | 1.6.1.2 | Découpes pour ouvertures | 5d | 2016-10-26 | 2016-11-01 | 42FF | 32d | 0d |
| 44 | 1.6.1.3 | pose menuiseries | 7d | 2016-11-02 | 2016-11-10 | 43 | 32d | 0d |
| 45 | 1.6.1.4 | étanchéité à l'air | 5d | 2016-11-11 | 2016-11-17 | 44 | 170d | 0d |
| 46 | 1.6.1.5 | encadrements ouvertures | 7d | 2016-11-18 | 2016-11-28 | 45 | 170d | 0d |
| 47 | 1.6.1.6 | isolation thermique façades | 20d | 2016-11-29 | 2016-12-26 | 46 | 170d | 0d |
| 48 | 1.6.1.7 | profils oméga | 15d | 2016-12-16 | 2017-01-05 | 47FS-7d | 170d | 0d |
| 49 | 1.6.1.8 | Bardages, tablettes | 20d | 2016-12-28 | 2017-01-24 | 48FS-7d | 170d | 0d |
| 50 | 1.6.1.9 | Contre bardage | 5d | 2017-01-03 | 2017-01-09 | 42, 57, 62 | 192d | 0d |
| 51 | 1.6.1.10 | stores BSO | 3d | 2017-01-25 | 2017-01-27 | 49 | 179d |  |
| 52 | 1.6.1.11 | couvertines | 5d | 2017-01-25 | 2017-01-31 | 49 | 177d |  |
| 53 | 1.6.1.12 | local EN-CV | 10d | 2017-01-25 | 2017-02-07 | 49 | 170d | 0d |
| 54 | 1.6.1.13 | Porte sectionnelle | 2d | 2016-11-29 | 2016-11-30 | 46 | 221d |  |
| 55 | 1.6.1.14 | Porte coulissante EV-CV | 2d | 2017-02-08 | 2017-02-09 | 53 | 170d |  |

| ID | WBS | Task | Duration | Start | Finish | Predecessors | Total slack | Free slack |
| --- | --- | --- | --- | --- | --- | --- | --- | --- |
| 56 | 1.6.2 | **Etanchéité - isolation - Ferblanterie** | 51d | 2016-11-02 | 2017-01-11 |  | 0d |  |
| 57 | 1.6.2.1 | Bacs porteurs d'étanchéité | 15d | 2016-11-02 | 2016-11-22 | 42 | 0d |  |
| 58 | 1.6.2.2 | lanterneaux | 4d | 2016-11-23 | 2016-11-28 | 57 | 223d |  |
| 59 | 1.6.2.3 | barrière de vapeur | 7d | 2016-11-23 | 2016-12-01 | 57 | 0d |  |
| 60 | 1.6.2.4 | isolation thermique toiture | 10d | 2016-12-02 | 2016-12-15 | 59 | 0d |  |
| 61 | 1.6.2.5 | étanchéité 1ère couche | 7d | 2016-12-16 | 2016-12-26 | 60 | 0d |  |
| 62 | 1.6.2.6 | relevés d'étanchéité | 5d | 2016-12-27 | 2017-01-02 | 61 | 191d | 0d |
| 63 | 1.6.2.7 | étanchéité 2ème couche | 7d | 2017-01-03 | 2017-01-11 | 62 | 191d |  |
| 64 | 1.6.2.8 | équipements lanterneaux | 3d | 2016-12-02 | 2016-12-06 | 59 | 217d |  |
| 65 | 1.6.3 | **Plâtrerie, plafonds, Menuiserie intérieure** | 88d | 2016-12-27 | 2017-04-27 |  | 0d |  |
| 66 | 1.6.3.1 | Ossature doublages | 5d | 2016-12-27 | 2017-01-02 | 44, 61 | 0d |  |
| 67 | 1.6.3.2 | Fermeture doublages | 4d | 2017-01-10 | 2017-01-13 | 66FS+5d | 1d | 0d |
| 68 | 1.6.3.3 | Portes intérieures | 5d | 2017-01-16 | 2017-01-20 | 67 | 1d | 0d |
| 69 | 1.6.3.4 | Ossature cloisons | 10d | 2017-01-23 | 2017-02-03 | 68 | 1d |  |
| 70 | 1.6.3.5 | Fermeture cloisons | 8d | 2017-02-14 | 2017-02-23 | 69FS+5d, 121, 133 | 0d |  |
| 71 | 1.6.3.6 | ossature plafonds | 7d | 2017-04-07 | 2017-04-17 | 90 | 119d | 0d |
| 72 | 1.6.3.7 | plaques plafonds | 3d | 2017-04-18 | 2017-04-20 | 71, 122 | 119d | 0d |
| 73 | 1.6.3.8 | luminaires, équipements de sécurité | 5d | 2017-04-21 | 2017-04-27 | 72 | 119d | 0d |
| 74 | 1.6.3.9 | Peinture parois | 6d | 2017-02-24 | 2017-03-03 | 70 | 161d |  |
| 75 | 1.6.4 | **Carrelage, faïences** | 31d | 2017-02-24 | 2017-04-07 |  | 132d |  |
| 76 | 1.6.4.1 | Etanchéité sous carrelage | 3d | 2017-02-24 | 2017-02-28 | 70 | 132d | 0d |
| 77 | 1.6.4.2 | pose carrelage sols | 5d | 2017-03-01 | 2017-03-07 | 76 | 132d | 0d |
| 78 | 1.6.4.3 | joints | 2d | 2017-03-08 | 2017-03-09 | 77 | 132d | 0d |
| 79 | 1.6.4.4 | spec | 3d | 2017-03-10 | 2017-03-14 | 78 | 132d | 0d |
| 80 | 1.6.4.5 | faiences murales | 15d | 2017-03-15 | 2017-04-04 | 79 | 132d | 0d |
| 81 | 1.6.4.6 | finitions | 3d | 2017-04-05 | 2017-04-07 | 80 | 132d | 0d |

| ID | WBS | Task | Type | Duration | Start | Finish | Predecessors | Total slack | Free slack |
| --- | --- | --- | --- | --- | --- | --- | --- | --- | --- |
| 82 | 1.6.5 | **Sols en résine - peintures** |  | 20d | 2017-02-24 | 2017-03-23 |  | 0d |  |
| 83 | 1.6.5.1 | préparation surfaces |  | 5d | 2017-02-24 | 2017-03-02 | 70 | 0d |  |
| 84 | 1.6.5.2 | revêtement polyuréthane sols |  | 10d | 2017-03-03 | 2017-03-16 | 83 | 0d |  |
| 85 | 1.6.5.3 | plinthes résine |  | 5d | 2017-03-17 | 2017-03-23 | 84 | 147d |  |
| 86 | 1.6.6 | **Cloisons amovibles** |  | 17d | 2017-03-17 | 2017-04-10 |  | 0d |  |
| 87 | 1.6.6.1 | Montage ossatures |  | 5d | 2017-03-17 | 2017-03-23 | 84 | 0d |  |
| 88 | 1.6.6.2 | Montage portes |  | 2d | 2017-03-24 | 2017-03-27 | 87 | 0d |  |
| 89 | 1.6.6.3 | installations techniques intégrées |  | 3d | 2017-03-28 | 2017-03-30 | 88 | 0d |  |
| 90 | 1.6.6.4 | pose panneaux |  | 5d | 2017-03-31 | 2017-04-06 | 89 | 0d |  |
| 91 | 1.6.6.5 | finitions |  | 2d | 2017-04-07 | 2017-04-10 | 90 | 135d |  |
| 92 | 1.6.7 | **Serrurerie bâtiment** |  | 19d | 2017-01-03 | 2017-01-27 |  | 186d |  |
| 93 | 1.6.7.1 | charpente escaliers |  | 5d | 2017-01-03 | 2017-01-09 | 66 | 186d | 0d |
| 94 | 1.6.7.2 | garde corps |  | 10d | 2017-01-10 | 2017-01-23 | 93 | 186d | 0d |
| 95 | 1.6.7.3 | finitions escaliers |  | 4d | 2017-01-24 | 2017-01-27 | 94 | 186d |  |
| 96 | 1.6.7.4 | garde-corps toiture |  | 8d | 2017-01-10 | 2017-01-19 | 50 | 192d |  |
| 97 | 1.6.8 | **Plomberie - Sanitaire** |  | 48d | 2017-02-24 | 2017-05-02 |  | 119d |  |
| 98 | 1.6.8.1 | tuyauteries E.U. |  | 2d | 2017-02-28 | 2017-03-01 | 99 | 163d |  |
| 99 | 1.6.8.2 | bâti supports Geberit |  | 2d | 2017-02-24 | 2017-02-27 | 69, 70 | 163d | 0d |
| 100 | 1.6.8.3 | appareillages sanitaires et accessoires |  | 4d | 2017-04-10 | 2017-04-13 | 81 | 132d |  |
| 101 | 1.6.8.4 | Pré-réception G.O. - S.O. |  | 3d | 2017-04-28 | 2017-05-02 | 73 | 119d | 0d |
| 102 | 1.6.8.5 | Livraison Gros-oeuvre, second oeuvre | milestone | 0d | 2017-05-02 | 2017-05-02 | 101 | 119d | 0d |
| 103 | 1.6.8.6 | Réception des travaux | milestone | 0d | 2017-05-02 | 2017-05-02 | 102 | 119d |  |
| 105 | 2 | **INTEGRATION B311** |  | 480d | 2015-12-15 | 2017-10-16 |  | 0d |  |
| 106 | 2.1 | **Ponts roulants** |  | 150d | 2016-02-24 | 2016-09-20 |  | 140d |  |
| 107 | 2.1.1 | conception |  | 1mo | 2016-02-24 | 2016-03-23 | 108SF | 409d |  |
| 108 | 2.1.2 | offres + choix du fabricant |  | 2mo | 2016-03-23 | 2016-05-18 | 109SF | 369d | 0d |
| 109 | 2.1.3 | plans d'execution |  | 1mo | 2016-05-18 | 2016-06-15 | 110SF | 349d | 0d |
| 110 | 2.1.4 | fabrication+tests |  | 3mo | 2016-06-15 | 2016-09-07 | 111SF | 289d | 0d |
| 111 | 2.1.5 | pose pont 40T |  | 1w | 2016-09-07 | 2016-09-13 | 33 | 0d |  |
| 112 | 2.1.6 | pose pont 5T |  | 1w | 2016-09-14 | 2016-09-20 | 111 | 279d |  |

| ID | WBS | Task | Duration | Start | Finish | Predecessors | Total slack | Free slack |
| --- | --- | --- | --- | --- | --- | --- | --- | --- |
| 113 | 2.2 | **Electricité** | 480d | 2015-12-15 | 2017-10-16 |  | 0d |  |
| 114 | 2.2.1 | mise à la terre | 2w | 2016-05-13 | 2016-07-19 | 12FS-1w | 0d |  |
| 115 | 2.2.2 | conception | 10w | 2015-12-15 | 2016-02-23 | 116SF | 430d |  |
| 116 | 2.2.3 | comité spécification | 4w | 2016-02-23 | 2016-03-22 | 117SF | 410d | 0d |
| 117 | 2.2.4 | appel offres | 2mo | 2016-03-22 | 2016-05-17 | 118SF | 370d | 0d |
| 118 | 2.2.5 | adjudication | 1mo | 2016-05-17 | 2016-06-14 | 119SF | 350d | 0d |
| 119 | 2.2.6 | plans d'execution | 6mo | 2016-06-14 | 2016-11-29 | 120SF | 230d | 0d |
| 120 | 2.2.7 | préparation chantier | 1mo | 2016-11-29 | 2016-12-27 | 121SF | 210d | 0d |
| 121 | 2.2.8 | incorporation dans cloisons | 7w | 2016-12-27 | 2017-02-13 | 66SS | 0d |  |
| 122 | 2.2.9 | incorporation en plafond | 12d | 2017-03-31 | 2017-04-17 | 90SS | 0d |  |
| 123 | 2.2.10 | distribution | 3mo | 2017-04-18 | 2017-07-10 | 122 | 0d |  |
| 124 | 2.2.11 | appareillage | 2mo | 2017-07-11 | 2017-09-04 | 123 | 0d |  |
| 125 | 2.2.12 | essais/mise en service | 1.5mo | 2017-09-05 | 2017-10-16 | 124 | 0d |  |
| 126 | 2.3 | **HVAC** | 480d | 2015-12-15 | 2017-10-16 |  | 0d |  |
| 127 | 2.3.1 | conception | 10w | 2015-12-15 | 2016-02-23 | 128SF | 430d |  |
| 128 | 2.3.2 | comité spécification | 4w | 2016-02-23 | 2016-03-22 | 129SF | 410d | 0d |
| 129 | 2.3.3 | appel offres | 2mo | 2016-03-22 | 2016-05-17 | 130SF | 370d | 0d |
| 130 | 2.3.4 | adjudication | 1mo | 2016-05-17 | 2016-06-14 | 131SF | 350d | 0d |
| 131 | 2.3.5 | plans d'execution | 6mo | 2016-06-14 | 2016-11-29 | 132SF | 230d | 0d |
| 132 | 2.3.6 | préparation chantier | 1mo | 2016-11-29 | 2016-12-27 | 133SF | 210d | 0d |
| 133 | 2.3.7 | incorporation dans cloison | 7w | 2016-12-27 | 2017-02-13 | 66SS | 0d |  |
| 134 | 2.3.8 | incorporation/distribution faux plafond | 1.5mo | 2017-03-07 | 2017-04-17 | 122FF | 0d |  |
| 135 | 2.3.9 | distribution | 3mo | 2017-04-18 | 2017-07-10 | 134 | 0d |  |
| 136 | 2.3.10 | appareillage | 2mo | 2017-07-11 | 2017-09-04 | 135 | 0d |  |
| 137 | 2.3.11 | essais/mise en service | 1.5mo | 2017-09-05 | 2017-10-16 | 136 | 0d |  |

| ID | WBS | Task | Duration | Start | Finish | Predecessors | Total slack | Free slack |
| --- | --- | --- | --- | --- | --- | --- | --- | --- |
| 138 | 2.4 | **Ascenseur** | 185d | 2017-01-31 | 2017-10-16 |  | 0d |  |
| 139 | 2.4.1 | conception | 1mo | 2017-01-31 | 2017-02-28 | 140SF | 165d |  |
| 140 | 2.4.2 | offres+choix entreprise/fabricant | 2mo | 2017-02-28 | 2017-04-25 | 141SF | 125d | 0d |
| 141 | 2.4.3 | plans d'execution | 2mo | 2017-04-25 | 2017-06-20 | 142SF | 85d | 0d |
| 142 | 2.4.4 | délais fabrication | 2mo | 2017-06-20 | 2017-08-15 | 143SF | 45d | 0d |
| 143 | 2.4.5 | pose ascenseur | 3w | 2017-08-15 | 2017-09-05 | 144SF | 30d | 0d |
| 144 | 2.4.6 | essais/mise en service | 1.5mo | 2017-09-05 | 2017-10-16 | 137FF | 0d |  |
| 145 | 2.5 | **Work package HVAC** | 50d | 2017-08-08 | 2017-10-16 |  | 0d |  |
| 146 | 2.5.1 | travaux/installation des locaux | 1mo | 2017-08-08 | 2017-09-05 | 147SF | 30d |  |
| 147 | 2.5.2 | essais finaux | 1.5mo | 2017-09-05 | 2017-10-16 | 137FF | 0d |  |
